Schedule from MS Project, 2022-07-15 to 2022-12-17.

## Calendars

- Casma- Huarmey: Mon-Sat 07:30-12:00, 13:00-17:30; Sun off.

## Schedule

| ID | WBS | Task | Type | Duration | Start | Finish | Predecessors | Total slack |
| --- | --- | --- | --- | --- | --- | --- | --- | --- |
| 1 | 1 | INICIO | milestone | 0d | 2022-07-15 | 2022-07-15 |  | 0d |
| 2 | 2 | **Proyecto “Entrega de las defensas ribereñas de los Ríos Casma y Huarmey – Paquete 4” - Proyecto 05 San Damián** |  | 150d | 2022-07-15 | 2022-12-17 |  | 0d |
| 3 | 2.1 | **OBRAS PROVISIONALES** |  | 90d | 2022-07-15 | 2022-10-15 |  | 0d |
| 4 | 2.1.1 | TRÁMITE, GESTIÓN Y OBTENCIÓN DE PERMISOS |  | 90d | 2022-07-15 | 2022-10-15 | 1 | 0d |
| 5 | 2.1.2 | CARTEL DE IDENTIFICACION DE LA OBRA DE 3.60M X 2.40M. |  | 2d | 2022-07-15 | 2022-07-16 | 1 | 148d |
| 6 | 2.1.3 | INSTALACIÓN DE CAMPAMENTO, PATIO TALLER Y OFICINAS |  | 5d | 2022-07-15 | 2022-07-20 | 1 | 0d |
| 7 | 2.2 | **OBRAS PRELIMINARES** |  | 150d | 2022-07-15 | 2022-12-17 |  | 0d |
| 8 | 2.2.1 | MOVILIZACIÓN Y DESMOVILIZACIÓN DE EQUIPOS Y/O MAQUINARIA |  | 10d | 2022-07-15 | 2022-07-25 | 1 | 140d |
| 9 | 2.2.2 | CONTROL TOPOGRAFICO DURANTE LA EJECUCIÓN |  | 150d | 2022-07-15 | 2022-12-17 | 1 | 0d |
| 10 | 2.2.3 | MANTENIMIENTO DE TRÁNSITO Y SEGURIDAD VIAL EN ACCESOS |  | 150d | 2022-07-15 | 2022-12-17 | 1 | 0d |
| 11 | 2.2.4 | HABILITACIÓN DE ACCESOS |  | 10d | 2022-07-20 | 2022-07-30 | 6 | 0d |
| 12 | 2.2.5 | CONSTRUCCIÓN E IMPLEMENTACIÓN DE POLVORÍN |  | 15d | 2022-07-15 | 2022-07-30 | 1 | 135d |
| 13 | 2.3 | **OPERACIÓN Y EXPLOTACION DE CANTERA** |  | 70d | 2022-08-31 | 2022-11-11 |  | 0d |
| 14 | 2.3.1 | EXTRACCIÓN DE ROCA EN CANTERA (CON EXPLOSIVOS) |  | 70d | 2022-08-31 | 2022-11-11 | 4SS+45d | 0d |
| 15 | 2.4 | **MOVIMIENTO DE TIERRAS** |  | 135d | 2022-07-22 | 2022-12-09 |  | 0d |
| 16 | 2.4.1 | DESBROCE Y LIMPIEZA |  | 10d | 2022-07-22 | 2022-08-02 | 11SS+2d | 0d |
| 17 | 2.4.2 | EXCAVACIÓN MASIVA EN MATERIAL SUELTO, CON EQUIPO |  | 23d | 2022-08-02 | 2022-08-25 | 16 | 0d |
| 18 | 2.4.3 | EXCAVACIÓN EN ROCA SUELTA CON EQUIPO |  | 12d | 2022-08-25 | 2022-09-07 | 17 | 98d |
| 19 | 2.4.4 | EXCAVACIÓN DE UÑA EN MATERIAL CON NIVEL FREÁTICO |  | 36d | 2022-08-25 | 2022-10-01 | 17 | 0d |
| 20 | 2.4.5 | CONFORMACIÓN Y COMPACTACIÓN DE DIQUE |  | 80d | 2022-08-16 | 2022-11-07 | 17SS+14d | 0d |
| 21 | 2.4.6 | REFINE Y PERFILADO DE TALUD |  | 88d | 2022-09-08 | 2022-12-08 | 24SS-1d | 9d |
| 22 | 2.4.7 | ENROCADO Y ACOMODO PARA PROTECCIÓN DE TALUD Y UÑA TIPO 2 |  | 70d | 2022-09-19 | 2022-12-01 | 23SS+12d | 1d |
| 23 | 2.4.8 | ENROCADO Y ACOMODO EN UÑA ANTISOCAVANTE TIPO 2 |  | 80d | 2022-09-07 | 2022-11-29 | 26SS+7d, 14SS+7d, 19SS+12d | 0d |
| 24 | 2.4.9 | RELLENO COMPACTADO CON MATERIAL PARA AFIRMADO EN CORONA |  | 88d | 2022-09-09 | 2022-12-09 | 23SS+2d, 20SS+23d | 0d |

| ID | WBS | Task | Type | Duration | Start | Finish | Predecessors | Total slack | Free slack |
| --- | --- | --- | --- | --- | --- | --- | --- | --- | --- |
| 25 | 2.5 | **OBRAS COMPLEMENTARIAS** |  | 123d | 2022-07-22 | 2022-11-26 |  | 20d |  |
| 26 | 2.5.1 | GEOTEXTIL NO TEJIDO CLASE 2, INCLUYE INSTALACIÓN |  | 89d | 2022-08-26 | 2022-11-26 | 20SS+10d, 19SS+1d | 4d |  |
| 27 | 2.5.2 | CONFORMACIÓN DE DME/DMO |  | 70d | 2022-07-22 | 2022-10-03 | 16SS | 73d | 0d |
| 28 | 2.6 | **TRANSPORTES DE MATERIAL** |  | 135d | 2022-07-22 | 2022-12-09 |  | 8d |  |
| 29 | 2.6.1 | TRANSPORTE DE MATERIAL GRANULAR PARA D<= 1KM |  | 111d | 2022-08-16 | 2022-12-09 | 20SS | 8d | 0d |
| 30 | 2.6.2 | TRANSPORTE DE MATERIAL GRANULAR PARA D> 1 KM |  | 111d | 2022-08-16 | 2022-12-09 | 29SS | 8d |  |
| 31 | 2.6.3 | TRANSPORTE DE DESECHOS Y EXCEDENTES A DME PARA D<= 1KM |  | 70d | 2022-07-22 | 2022-10-03 | 27SS | 73d |  |
| 32 | 2.6.4 | TRANSPORTE DE DESECHOS Y EXCEDENTES A DME: PARA D> 1KM |  | 70d | 2022-07-22 | 2022-10-03 | 27SS | 73d |  |
| 33 | 2.6.5 | TRANSPORTE DE ROCA PARA D<= 1 KM |  | 86d | 2022-09-07 | 2022-12-05 | 23SS | 12d | 0d |
| 34 | 2.6.6 | TRANSPORTE DE ROCA PARA D> 1 KM |  | 86d | 2022-09-07 | 2022-12-05 | 33SS | 12d |  |
| 35 | 2.7 | **TRABAJOS DE CIERRE** |  | 150d | 2022-07-15 | 2022-12-17 |  | 0d |  |
| 36 | 2.7.1 | LIMPIEZA Y NIVELACIÓN DEL TERRENO |  | 15d | 2022-12-02 | 2022-12-17 | 22, 24FS-7d | 0d |  |
| 37 | 2.7.2 | MITIGACIÓN DE IMPACTO AMBIENTAL |  | 150d | 2022-07-15 | 2022-12-17 | 1 | 0d |  |
| 38 | 3 | FIN | milestone | 0d | 2022-12-17 | 2022-12-17 | 36 | 0d |  |
